# OJP Transition Schedule v3 - Notes

Schedule from MS Project, 2006-09-28 to 2006-10-30, A marks actual dates.

## Calendars

- Standard: Mon-Fri 08:00-12:00, 13:00-17:00; Sat-Sun off. Exceptions (off unless hours are given): 2006-10-07 to 2006-10-08 08:00-12:00, 13:00-17:00.

## Resources

| Resource |
| --- |
| Project Manager |
| Dave Jefferson |
| Andrea Adkins |
| Mark Jefferson |
| Ann LaForce |
| Task Leads |
| Bruce Forshay |
| Paul Ray |
| Victor Pham |
| Pul |

## Schedule

| ID | WBS | Task | Duration | Start | Finish | Predecessors | Complete | Remaining | Baseline start | Baseline finish | Baseline duration | Total slack | Free slack | Constraint | Deadline | Resources | Work | Actual work |
| --- | --- | --- | --- | --- | --- | --- | --- | --- | --- | --- | --- | --- | --- | --- | --- | --- | --- | --- |
| 1 | 1 | **OJP Administrative Tasks** | 20d? | 2006-09-28 A | 2006-10-23 |  | 15% | 17.03d? | 2006-09-28 | 2006-10-27 | 24d? | 5d |  |  |  |  | 357h | 53h |
| 2 | 1.1 | **Contract Award Transition Activities** | 13d? | 2006-09-28 A | 2006-10-12 |  | 24% | 9.9d? | 2006-09-28 | 2006-10-27 | 24d? | 12d |  |  |  |  | 21h | 5h |
| 3 | 1.1.1 | Hold Kick-Off Meeting | 3h | 2006-09-28 A | 2006-09-28 A |  | 100% |  | 2006-09-28 | 2006-09-28 | 1d? |  |  | start no earlier than 2006-09-28 |  | Mark Jefferson | 3h | 3h |
| 4 | 1.1.2 | Meet with OJP Security Office | 2h | 2006-10-05 A | 2006-10-05 A |  | 100% |  | 2006-10-02 | 2006-10-02 | 1d? |  |  |  |  | Mark Jefferson | 2h | 2h |
| 5 | 1.1.3 | Meet with OJP COTR | 1d? | 2006-10-02 | 2006-10-02 |  |  |  |  |  |  | 22d |  |  |  | Mark Jefferson | 8h |  |
| 6 | 1.1.4 | Establish POCs | 8h | 2006-10-12 | 2006-10-12 |  |  |  | 2006-10-03 | 2006-10-03 | 1d? | 12d |  | start no earlier than 2006-10-12 |  | Mark Jefferson | 8h |  |
| 7 | 1.2 | **Security Clearances** | 5d | 2006-10-02 A | 2006-10-06 A |  | 100% |  | 2006-10-02 | 2006-10-11 | 10d? |  |  |  |  |  | 48h | 48h |
| 8 | 1.2.1 | Meet with OJP Security Office | 1d | 2006-10-03 A | 2006-10-03 A |  | 100% |  | 2006-10-03 | 2006-10-03 | 1d? |  |  | start no earlier than 2006-10-03 |  | Andrea Adkins | 8h | 8h |
| 9 | 1.2.2 | WINS Security Manager Develop Security Clearance and Site Visit | 5d | 2006-10-02 A | 2006-10-06 A |  | 100% |  | 2006-10-02 | 2006-10-06 | 5d? |  |  |  |  | Andrea Adkins | 40h | 40h |
| 10 | 1.3 | **Project Staffing** | 10d | 2006-10-10 | 2006-10-23 |  |  |  |  |  |  | 5d |  |  |  |  | 240h |  |
| 11 | 1.3.1 | Develop Staffing Schedule | 10d | 2006-10-10 | 2006-10-23 |  |  |  |  |  |  | 5d |  | finish no earlier than 2006-10-23 |  | Dave Jefferson | 80h |  |
| 12 | 1.3.2 | Conduct Employee Orientation (ongoing) | 10d | 2006-10-10 | 2006-10-23 |  |  |  |  |  |  | 5d |  | finish no earlier than 2006-10-23 |  | Ann LaForce | 80h |  |
| 13 | 1.3.3 | Conduct SOP Training (ongoing) | 10d | 2006-10-10 | 2006-10-23 |  |  |  |  |  |  | 5d |  | finish no earlier than 2006-10-23 |  | Task Leads | 80h |  |
| 14 | 1.4 | **GFE Review** | 5d | 2006-10-16 | 2006-10-20 |  |  |  | 2006-10-04 | 2006-10-09 | 6d? | 6d |  |  |  |  | 48h |  |
| 15 | 1.4.1 | Conduct GFE Baseline Audit | 5d | 2006-10-16 | 2006-10-20 |  |  |  | 2006-10-08 | 2006-10-08 | 1d? | 6d |  | start no earlier than 2006-10-16 |  | Dave Jefferson | 40h |  |
| 16 | 1.4.2 | Obtain and Review OJP GFE policy and Procedures | 1d | 2006-10-16 | 2006-10-16 |  |  |  | 2006-10-04 | 2006-10-06 | 3d? | 10d |  | start no earlier than 2006-10-16 |  | Dave Jefferson | 8h |  |
| 17 | 2 | **Baselining Tasks** | 23d? | 2006-10-02 | 2006-10-30 |  |  |  | 2006-10-02 | 2006-12-15 | 57d? | 0d |  |  |  |  | 1232h |  |
| 18 | 2.1 | **Task One Project Management** | 13d? | 2006-10-12 | 2006-10-30 |  |  |  | 2006-10-05 | 2006-10-18 | 12d? | -5d | 0d |  |  |  | 344h |  |
| 19 | 2.1.1 | **Review Current Project Plan and Documentation** | 7d | 2006-10-12 | 2006-10-20 |  |  |  | 2006-10-08 | 2006-10-10 | 3d? | -5d | 0d |  |  |  | 88h |  |
| 20 | 2.1.1.1 | Review Current Staff Matrix | 1d | 2006-10-12 | 2006-10-12 |  |  |  | 2006-10-07 | 2006-10-10 | 3.5d? | -5d | 0d | start no earlier than 2006-10-12 |  | Dave Jefferson | 8h |  |
| 21 | 2.1.1.2 | Review On Call Plan list | 1d | 2006-10-16 | 2006-10-16 | 20 |  |  | 2006-10-16 | 2006-10-18 | 3d? | -6d | 0d | start no earlier than 2006-10-16 |  | Dave Jefferson | 8h |  |
| 22 | 2.1.1.3 | Review Previous Project Management Preports | 2d | 2006-10-17 | 2006-10-18 | 21 |  |  | 2006-10-07 | 2006-10-07 | 1d? | -6d | 0d |  | 2006-10-10 | Dave Jefferson | 16h |  |
| 23 | 2.1.1.4 | Review OJP Change Management Procedures | 2d | 2006-10-19 | 2006-10-20 | 22 |  |  | 2006-10-18 | 2006-10-24 | 4.5d? | 1d |  | start no earlier than 2006-10-18 |  | Dave Jefferson | 16h |  |
| 24 | 2.1.1.5 | Review SDLC processes | 5d | 2006-10-13 | 2006-10-19 | 20 |  |  | 2006-10-09 | 2006-10-18 | 8d? | 1d | 0d | start no earlier than 2006-10-09 |  | Dave Jefferson | 40h |  |

| ID | WBS | Task | Duration | Start | Finish | Predecessors | Baseline start | Baseline finish | Baseline duration | Total slack | Free slack | Constraint | Resources | Work |
| --- | --- | --- | --- | --- | --- | --- | --- | --- | --- | --- | --- | --- | --- | --- |
| 25 | 2.1.2 | **Establish OJP Service Level Agreements** | 10d | 2006-10-16 | 2006-10-27 |  | 2006-10-16 | 2006-10-23 | 6d? | 1d |  |  |  | 80h |
| 26 | 2.1.2.1 | Review new SLA Metrics | 2d | 2006-10-16 | 2006-10-17 |  | 2006-10-16 | 2006-10-17 | 2d? | 1d | 0d | start no earlier than 2006-10-16 | Dave Jefferson | 16h |
| 27 | 2.1.2.2 | Develop SLA Data gathering process & procedures | 8d | 2006-10-18 | 2006-10-27 | 26 | 2006-10-18 | 2006-10-18 | 1d? | 1d |  | start no earlier than 2006-10-18 | Dave Jefferson | 64h |
| 28 | 2.1.3 | **OJP Standard Operating Procedures (SOP) Review** | 11d? | 2006-10-16 | 2006-10-30 |  | 2006-10-03 | 2006-10-27 | 21d? | 0d |  |  |  | 88h |
| 29 | 2.1.3.1 | Review Current OJP SOPs | 5d | 2006-10-16 | 2006-10-20 |  | 2006-10-03 | 2006-10-09 | 7d? | 0d |  | start no earlier than 2006-10-16 | Task Leads | 40h |
| 30 | 2.1.3.2 | Validate SOPs | 1d? | 2006-10-23 | 2006-10-23 | 29 |  |  |  | 0d |  |  | Task Leads | 8h |
| 31 | 2.1.3.3 | Organize SOP By Task Areas | 5d | 2006-10-24 | 2006-10-30 | 30 | 2006-10-23 | 2006-10-27 | 5d? | 0d |  | start no earlier than 2006-10-22 | Task Leads | 40h |
| 32 | 2.1.4 | **OJP Audit Review** | 6d | 2006-10-20 | 2006-10-27 |  | 2006-10-02 | 2006-10-19 | 16d? | 1d |  |  |  | 48h |
| 33 | 2.1.4.1 | Obtain most current Audit Reports | 5d | 2006-10-20 | 2006-10-26 | 24 | 2006-10-03 | 2006-10-08 | 6d? | 1d | 0d | start no earlier than 2006-10-03 | Dave Jefferson | 40h |
| 34 | 2.1.4.2 | Identify Future Audit Dates | 1d | 2006-10-27 | 2006-10-27 | 33 | 2006-10-10 | 2006-10-19 | 8d? | 1d |  | start no earlier than 2006-10-10 | Dave Jefferson | 8h |
| 35 | 2.1.5 | **Develop Staffing Matrix** | 5d | 2006-10-23 | 2006-10-27 |  | 2006-10-08 | 2006-10-10 | 3d? | 1d |  |  |  | 40h |
| 36 | 2.1.5.1 | Develop Work Schedule | 2d | 2006-10-23 | 2006-10-24 | 19 | 2006-10-10 | 2006-10-10 | 1d? | 1d | 0d | start no earlier than 2006-10-10 | Dave Jefferson | 16h |
| 37 | 2.1.5.2 | Allign staffing Matrix with Task areas | 3d | 2006-10-25 | 2006-10-27 | 36 | 2006-10-09 | 2006-10-09 | 1d? | 1d |  | finish no earlier than 2006-10-09 | Dave Jefferson | 24h |
| 38 | 2.2 | **Task Two: Help Desk and User Support** | 12d | 2006-10-12 | 2006-10-27 |  | 2006-10-09 | 2006-10-27 | 15d? | 1d |  |  |  | 432h |
| 39 | 2.2.1 | **Senior Management and Executive (VIP) Support** | 10d | 2006-10-16 | 2006-10-27 |  | 2006-10-08 | 2006-10-27 | 16d? | 1d |  |  |  | 72h |
| 40 | 2.2.1.1 | Capture VIP Support List | 1d | 2006-10-16 | 2006-10-16 |  | 2006-10-08 | 2006-10-17 | 7.5d? | 2d | 0d | start no earlier than 2006-10-16 | Bruce Forshay | 8h |
| 41 | 2.2.1.2 | Review VIP support Procedures | 3d | 2006-10-17 | 2006-10-19 | 40 | 2006-10-08 | 2006-10-18 | 8.5d? | 2d | 1d | start no earlier than 2006-10-08 | Bruce Forshay | 24h |
| 42 | 2.2.1.3 | Develop and conduct Customer Service Training | 5d | 2006-10-23 | 2006-10-27 | 41 | 2006-10-23 | 2006-10-27 | 5d? | 1d |  | start no earlier than 2006-10-23 | Bruce Forshay | 40h |
| 43 | 2.2.2 | **Help Desks and User Suppot Areas** | 12d | 2006-10-12 | 2006-10-27 |  | 2006-10-09 | 2006-10-27 | 14.5d? | 1d |  |  |  | 272h |
| 44 | 2.2.2.1 | Review Help Desk Procedures | 2d | 2006-10-12 | 2006-10-13 |  | 2006-10-09 | 2006-10-20 | 10d? | 2d | 0d | start no earlier than 2006-10-12 | Bruce Forshay | 16h |
| 45 | 2.2.2.2 | Review Desktop and Portable Computing Support Process | 2d | 2006-10-16 | 2006-10-17 | 44 | 2006-10-10 | 2006-10-24 | 11d? | 9d |  | start no earlier than 2006-10-13 | Bruce Forshay | 16h |
| 46 | 2.2.2.3 | Review Heat System | 5d | 2006-10-17 | 2006-10-23 | 44 | 2006-10-17 | 2006-10-24 | 6d? | 1d | 0d | start no earlier than 2006-10-17 | Bruce Forshay | 40h |
| 47 | 2.2.2.4 | COTS Software Maintenance and Support | 2d | 2006-10-24 | 2006-10-25 | 46 | 2006-10-10 | 2006-10-23 | 10d? | 1d | 0d | start no earlier than 2006-10-10 | Bruce Forshay | 16h |
| 48 | 2.2.2.5 | Hardware/Software migrations and rollouts | 2d | 2006-10-26 | 2006-10-27 | 47 | 2006-10-19 | 2006-10-26 | 6d? | 1d |  | start no earlier than 2006-10-19 | Bruce Forshay | 16h |
| 49 | 2.2.2.6 | Review Existing User Training | 2d | 2006-10-24 | 2006-10-25 | 46 | 2006-10-19 | 2006-10-25 | 5d? | 3d |  | start no earlier than 2006-10-19 | Bruce Forshay | 16h |
| 50 | 2.2.2.7 | Inventory control of all hardware and software | 2d | 2006-10-24 | 2006-10-25 | 46 | 2006-10-24 | 2006-10-26 | 2.5d? | 1d | 0d | start no earlier than 2006-10-24 | Bruce Forshay | 16h |
| 51 | 2.2.2.8 | Intranet/Internet related problems and support | 2d | 2006-10-26 | 2006-10-27 | 50 | 2006-10-10 | 2006-10-13 | 3.5d? | 1d |  | start no earlier than 2006-10-10 | Bruce Forshay | 16h |

| ID | WBS | Task | Duration | Start | Finish | Predecessors | Baseline start | Baseline finish | Baseline duration | Total slack | Free slack | Constraint | Resources | Work |
| --- | --- | --- | --- | --- | --- | --- | --- | --- | --- | --- | --- | --- | --- | --- |
| 52 | 2.2.2.9 | **Tracking metrics for Help Desk** | 10d | 2006-10-16 | 2006-10-27 |  |  |  |  | 1d |  |  |  | 80h |
| 53 | 2.2.2.9.1 | Customer satisfaction surveys | 1d | 2006-10-16 | 2006-10-16 |  | 2006-10-23 | 2006-10-26 | 3.5d? | 1d | 0d | start no earlier than 2006-10-16 | Bruce Forshay | 8h |
| 54 | 2.2.2.9.2 | Customer trend tracking | 2d | 2006-10-17 | 2006-10-18 | 53 | 2006-10-23 | 2006-10-24 | 2d? | 1d | 0d |  | Bruce Forshay | 16h |
| 55 | 2.2.2.9.3 | Number of open tickets overall | 2d | 2006-10-19 | 2006-10-20 | 54 | 2006-10-26 | 2006-10-26 | 1d? | 1d | 0d |  | Bruce Forshay | 16h |
| 56 | 2.2.2.9.4 | Number of tickets opened during month | 1d | 2006-10-23 | 2006-10-23 | 55 | 2006-10-26 | 2006-10-26 | 1d? | 1d | 0d |  | Bruce Forshay | 8h |
| 57 | 2.2.2.9.5 | Number of tickets closed during month | 1d | 2006-10-24 | 2006-10-24 | 56 | 2006-10-26 | 2006-10-26 | 1d? | 1d | 0d |  | Bruce Forshay | 8h |
| 58 | 2.2.2.9.6 | Oldest open tickets | 1d | 2006-10-25 | 2006-10-25 | 57 | 2006-10-26 | 2006-10-26 | 1d? | 1d | 0d |  | Bruce Forshay | 8h |
| 59 | 2.2.2.9.7 | Help desks reference materials | 2d | 2006-10-26 | 2006-10-27 | 58 | 2006-10-08 | 2006-10-19 | 10d? | 1d |  |  | Bruce Forshay | 16h |
| 60 | 2.2.2.10 | **Tracking metrics for ACD** | 9d | 2006-10-16 | 2006-10-26 |  | 2006-10-23 | 2006-10-23 | 1d? | 2d |  |  |  | 40h |
| 61 | 2.2.2.10.1 | Number received during month | 1d | 2006-10-16 | 2006-10-16 |  | 2006-10-23 | 2006-10-23 | 1d? | 6d | 4d | start no earlier than 2006-10-16 | Bruce Forshay | 8h |
| 62 | 2.2.2.10.2 | Number terminated before reaching representative | 1d | 2006-10-23 | 2006-10-23 | 61 | 2006-10-23 | 2006-10-23 | 1d? | 2d | 0d | start no earlier than 2006-10-22 | Bruce Forshay | 8h |
| 63 | 2.2.2.10.3 | Number receiving busy signal | 1d | 2006-10-24 | 2006-10-24 | 62 | 2006-10-23 | 2006-10-23 | 1d? | 2d | 0d | start no earlier than 2006-10-23 | Bruce Forshay | 8h |
| 64 | 2.2.2.10.4 | Average wait time for the month | 1d | 2006-10-25 | 2006-10-25 | 63 | 2006-10-23 | 2006-10-23 | 1d? | 2d | 0d | start no earlier than 2006-10-22 | Bruce Forshay | 8h |
| 65 | 2.2.2.10.5 | Longest wait time for the month | 1d | 2006-10-26 | 2006-10-26 | 64 | 2006-10-23 | 2006-10-23 | 1d? | 2d |  | start no earlier than 2006-10-22 | Bruce Forshay | 8h |
| 66 | 2.2.3 | **Grants Management System Support** | 11d | 2006-10-13 | 2006-10-27 |  | 2006-10-11 | 2006-10-17 | 4.5d? | 1d |  |  |  | 88h |
| 67 | 2.2.3.1 | Review Grants Management Staffing Matrix (7AM-7PM) | 1d | 2006-10-13 | 2006-10-13 |  | 2006-10-11 | 2006-10-13 | 2.5d? | 11d |  | start no earlier than 2006-10-13 | Bruce Forshay | 8h |
| 68 | 2.2.3.2 | Review all GSM user manuals, Administration Manuals | 5d | 2006-10-16 | 2006-10-20 |  | 2006-10-11 | 2006-10-16 | 4d? | 1d | 0d | start no earlier than 2006-10-16 | Bruce Forshay | 40h |
| 69 | 2.2.3.3 | Review GSM Help Desk Procedures | 3d | 2006-10-23 | 2006-10-25 | 68 | 2006-10-10 | 2006-10-23 | 10d? | 1d | 0d | start no earlier than 2006-10-10 | Bruce Forshay | 24h |
| 70 | 2.2.3.4 | Review Grants Life Cycle | 2d | 2006-10-26 | 2006-10-27 | 69 | 2006-10-12 | 2006-10-17 | 3.5d? | 1d |  | start no earlier than 2006-10-12 | Bruce Forshay | 16h |
| 71 | 2.3 | **Task Three: Information Technology Facilities Operations Support** | 12d | 2006-10-12 | 2006-10-27 |  | 2006-10-02 | 2006-10-30 | 23d? | 1d |  |  |  | 392h |
| 72 | 2.3.1 | Review Network Operations Center (NOC) | 5d | 2006-10-12 | 2006-10-18 |  | 2006-10-12 | 2006-10-25 | 9.5d? | 1d | 0d | start no earlier than 2006-10-12 | Paul Ray | 40h |
| 73 | 2.3.2 | Review OJP Enterprise Architecture | 5d | 2006-10-19 | 2006-10-25 | 72 | 2006-10-12 | 2006-10-16 | 3d? | 1d | 0d | start no earlier than 2006-10-12 | Paul Ray | 40h |
| 74 | 2.3.3 | Review COOP and ITCP Support | 2d | 2006-10-26 | 2006-10-27 | 73 | 2006-10-20 | 2006-10-23 | 2d? | 1d |  | start no earlier than 2006-10-16 | Victor Pham | 16h |
| 75 | 2.3.4 | Review LAN/WAN Topology & Connectivity | 3d | 2006-10-16 | 2006-10-18 |  | 2006-10-11 | 2006-10-24 | 10d? | 8d |  | start no earlier than 2006-10-16 | Paul Ray | 24h |
| 76 | 2.3.5 | Review Microsoft Servers | 5d | 2006-10-16 | 2006-10-20 |  | 2006-10-13 | 2006-10-17 | 3d? | 4d | 0d | start no earlier than 2006-10-16 | Paul Ray | 40h |
| 77 | 2.3.6 | Review Security Patch Processes, Patch Level and patch levels | 2d | 2006-10-23 | 2006-10-24 | 76 | 2006-10-11 | 2006-10-18 | 6d? | 4d |  | start no earlier than 2006-10-11 | Paul Ray | 16h |
| 78 | 2.3.7 | Review UNIX Enterprise Servers | 5d | 2006-10-16 | 2006-10-20 |  | 2006-10-12 | 2006-10-17 | 4d? | 1d | 0d | start no earlier than 2006-10-16 | Victor Pham | 40h |
| 79 | 2.3.8 | Review Firewall and Virus Protection System | 5d | 2006-10-23 | 2006-10-27 | 78 | 2006-10-10 | 2006-10-17 | 6d? | 1d |  | start no earlier than 2006-10-10 | Victor Pham | 40h |
| 80 | 2.3.9 | Review Email System | 3d | 2006-10-16 | 2006-10-18 |  | 2006-10-16 | 2006-10-19 | 4d? | 1d | 0d | start no earlier than 2006-10-15 | Paul Ray | 24h |
| 81 | 2.3.10 | Enterprise network backup/restore operation using Veritas and Overland Tape Library System | 2d | 2006-10-19 | 2006-10-20 | 80 | 2006-10-02 | 2006-10-02 | 1d? | 1d | 0d | start no earlier than 2006-10-16 | Paul Ray | 16h |
| 82 | 2.3.11 | Review Oracle, SQL Servers and Other Databases | 5d | 2006-10-23 | 2006-10-27 | 81 | 2006-10-11 | 2006-10-16 | 4d? | 1d |  | start no earlier than 2006-10-11 | Victor Pham | 40h |
| 83 | 2.3.12 | CA eTrust and Unicenter tools maintenance and support | 2d | 2006-10-16 | 2006-10-17 |  | 2006-10-09 | 2006-10-19 | 8.5d? | 4d | 2d | start no earlier than 2006-10-16 | Victor Pham | 16h |
| 84 | 2.3.13 | Remote Access and Citrix support | 3d | 2006-10-20 | 2006-10-24 | 83 | 2006-10-20 | 2006-10-25 | 3.5d? | 2d | 0d | start no earlier than 2006-10-20 | Paul Ray | 24h |
| 85 | 2.3.14 | SANS Storage management and support, including EMC storage devices | 2d | 2006-10-25 | 2006-10-26 | 84 | 2006-10-09 | 2006-10-11 | 3d? | 2d |  | start no earlier than 2006-10-09 | Paul Ray | 16h |

| ID | WBS | Task | Duration | Start | Finish | Predecessors | Baseline start | Baseline finish | Baseline duration | Total slack | Free slack | Constraint | Resources | Work |
| --- | --- | --- | --- | --- | --- | --- | --- | --- | --- | --- | --- | --- | --- | --- |
| 86 | 2.4 | **Task Four: Enterprise Operations Strategic Support** | 8d | 2006-10-16 | 2006-10-25 |  | 2006-10-16 | 2006-10-24 | 6.5d? | 3d |  |  |  | 64h |
| 87 | 2.4.1 | Yearly OMB reporting requirements | 2d | 2006-10-16 | 2006-10-17 |  | 2006-10-02 | 2006-10-02 | 1d? | 3d | 0d | start no earlier than 2006-10-16 | Dave Jefferson | 16h |
| 88 | 2.4.2 | E-Government initiative planning and support | 2d | 2006-10-18 | 2006-10-19 | 87 | 2006-10-02 | 2006-10-02 | 1d? | 3d | 0d | start no earlier than 2006-10-17 | Dave Jefferson | 16h |
| 89 | 2.4.3 | Equipment lifecycle management and replacement | 2d | 2006-10-20 | 2006-10-23 | 88 | 2006-10-02 | 2006-10-02 | 1d? | 3d | 0d | start no earlier than 2006-10-19 | Dave Jefferson | 16h |
| 90 | 2.4.4 | Renewal of software licenses | 2d | 2006-10-24 | 2006-10-25 | 89 | 2006-10-02 | 2006-10-02 | 1d? | 3d |  | start no earlier than 2006-10-18 | Dave Jefferson | 16h |
| 91 | 2.5 | Add a Closeout Session | 1d? | 2006-10-02 | 2006-10-02 |  |  |  |  | 22d |  |  |  |  |
| 92 | 2.6 | Send a list of meetings for next week | 1d? | 2006-10-02 | 2006-10-02 |  |  |  |  | 22d |  |  |  |  |
